# Construction of 200000 GAL Capacity Water Tank

Schedule from Primavera P6, 2021-02-01 to 2021-04-26, data date 2021-01-31.
Must finish by 2021-04-30

## Calendars

- 5x10: Mon-Fri 07:00-12:00, 13:00-18:00; Sat-Sun off.

## Resources

| Resource | Group |
| --- | --- |
| Engineer | labor |
| Labour | labor |
| Excavator | equipment |
| Mason | labor |
| Steel Fixer | labor |
| Fixer Helper | labor |
| Scaffolder | labor |
| Carpenter | labor |

## Schedule

| ID | WBS | Activity | Type | Duration | Start | Finish | Predecessors | Total float | Free float | Resources |
| --- | --- | --- | --- | --- | --- | --- | --- | --- | --- | --- |
|  | 1 | **Preliminary Stage** |  |  | 2021-02-01 | 2021-04-26 |  |  |  |  |
| A1000 |  | Project Start | milestone | 0d | 2021-02-01 | 2021-02-01 |  | 3.36d | 0d |  |
| A1010 |  | Project Moblization |  | 1d | 2021-02-01 | 2021-02-01 | A1000 | 3.36d | 0d | Engineer [10 h] |
| A1020 |  | Primary Works to Start Project |  | 1d | 2021-02-02 | 2021-02-02 | A1010 | 3.36d | 0d | Engineer [40 h] |
| A1150 |  | Project Finish | milestone | 0d | 2021-04-26 | 2021-04-26 | A1140 | 3.36d | 0d |  |
|  | 2 | **Construction Stage** |  |  | 2021-02-03 | 2021-04-22 |  |  |  |  |
| A1030 |  | Cleaning and Grabing of Site |  | 1.8d | 2021-02-03 | 2021-02-04 | A1020 | 3.36d | 0d | Engineer [8 h]; Labour [43.2 h] |
| A1040 |  | Site Survey Work |  | 1.35d | 2021-02-04 | 2021-02-08 | A1030 | 3.36d | 0d | Engineer [32 h]; Labour [43.2 h] |
| A1050 |  | Excavation Work |  | 2.19d | 2021-02-08 | 2021-02-10 | A1040 | 3.36d | 0d | Engineer [40 h]; Excavator [70.16 h] |
| A1060 |  | P.C.C Work |  | 3.25d | 2021-02-10 | 2021-02-15 | A1050 | 3.36d | 0d | Engineer [26.67 h]; Mason [52 h]; Labour [130 h] |
| A1070 |  | Raft Foundation Work |  | 16.21d | 2021-02-15 | 2021-03-09 | A1060 | 3.36d | 0d | Engineer [156 h]; Mason [156 h]; Labour [389 h]; Steel Fixer [4 h]; Fixer Helper [156 h]; Scaffolder [156 h]; Carpenter [311 h] |
| A1080 |  | Column Concrete Work |  | 11.55d | 2021-03-09 | 2021-03-25 | A1070 | 3.36d | 0d | Engineer [16 h]; Mason [104 h]; Labour [260 h]; Steel Fixer [104 h]; Fixer Helper [104 h]; Scaffolder [104 h]; Carpenter [208 h] |
| A1090 |  | Shear Wall Concrete Work |  | 9.29d | 2021-03-25 | 2021-04-07 | A1080 | 3.36d | 0d | Engineer [16 h]; Mason [208 h]; Labour [520 h]; Steel Fixer [208 h]; Fixer Helper [208 h]; Scaffolder [208 h]; Carpenter [416 h] |
| A1100 |  | MEP Fiiting in Walls |  | 1d | 2021-04-07 | 2021-04-08 | A1090 | 3.36d | 0d | Engineer [40 h] |
| A1110 |  | Water Tank Slab Concrete |  | 6.67d | 2021-04-08 | 2021-04-19 | A1100 | 3.36d | 0d | Engineer [16 h]; Mason [128 h]; Labour [320 h]; Steel Fixer [128 h]; Fixer Helper [128 h]; Scaffolder [128 h]; Carpenter [256 h] |
| A1120 |  | Backfliing Work |  | 3.33d | 2021-04-19 | 2021-04-22 | A1110 | 3.36d | 0d | Engineer [32 h]; Labour [160 h] |
|  | 3 | **Completion Stage** |  |  | 2021-04-22 | 2021-04-26 |  |  |  |  |
| A1130 |  | Project Handover |  | 1d | 2021-04-22 | 2021-04-23 | A1120 | 3.36d | 0d | Engineer [40 h] |
| A1140 |  | Demoblization |  | 1d | 2021-04-23 | 2021-04-26 | A1130 | 3.36d | 0d | Engineer [40 h] |
